# kerites_megold

Schedule from MS Project, 2011-10-29 to 2011-11-16, 7 hours a day, costs in Ft.
Rempo Rt

## Calendars

- otthoni: Mon-Sun 09:00-12:00, 14:00-18:00.

## Resources

| Resource | Unit | Rate |
| --- | --- | --- |
| apa |  |  |
| fia |  |  |
| szerszámok |  |  |
| oszlopok | db | 200 |
| faanyag | m2 | 300 |
| cement | zsák | 500 |
| drótkerítés | m | 400 |

## Schedule

| ID | WBS | Task | Duration | Start | Finish | Predecessors | Total slack | Constraint | Resources | Work | Cost |
| --- | --- | --- | --- | --- | --- | --- | --- | --- | --- | --- | --- |
| 1 | 1 | Alap kijelölése | 1d | 2011-10-29 09:00 | 2011-10-29 18:00 |  | 0d |  | apa; fia; szerszámok | 21h |  |
| 2 | 2 | Alap kiásása | 3d | 2011-10-30 09:00 | 2011-11-01 18:00 | 1 | 0d |  | apa; fia; szerszámok | 63h |  |
| 3 | 3 | Oszlopok helyeinek jelölése | 1h | 2011-11-02 09:00 | 2011-11-02 10:00 | 2 | 0d |  | apa; fia; szerszámok | 3h |  |
| 4 | 4 | Zsaluzás | 6h | 2011-11-02 10:00 | 2011-11-02 18:00 | 3 | 0d |  | apa; fia; szerszámok; faanyag [20 m2] | 18h | 6,000 |
| 5 | 5 | Oszlopok elhelyezése | 1d | 2011-11-03 09:00 | 2011-11-03 18:00 | 4 | 0d |  | apa; fia; szerszámok; oszlopok [20 db] | 21h | 4,000 |
| 6 | 6 | Betonozás | 2d | 2011-11-04 09:00 | 2011-11-05 18:00 | 5 | 0d |  | apa; fia; szerszámok; cement [10 zsák] | 42h | 5,000 |
| 7 | 7 | **Beton öntözése** | 6.14d | 2011-11-06 17:00 | 2011-11-12 18:00 | 6 | 0d |  |  |  |  |
| 8 | 7.1 | Beton öntözése 1 | 1h | 2011-11-06 17:00 | 2011-11-06 18:00 |  | 6d | start no earlier than 2011-11-06 17:00 |  |  |  |
| 9 | 7.2 | Beton öntözése 2 | 1h | 2011-11-07 17:00 | 2011-11-07 18:00 |  | 5d | start no earlier than 2011-11-07 17:00 |  |  |  |
| 10 | 7.3 | Beton öntözése 3 | 1h | 2011-11-08 17:00 | 2011-11-08 18:00 |  | 4d | start no earlier than 2011-11-08 17:00 |  |  |  |
| 11 | 7.4 | Beton öntözése 4 | 1h | 2011-11-09 17:00 | 2011-11-09 18:00 |  | 3d | start no earlier than 2011-11-09 17:00 |  |  |  |
| 12 | 7.5 | Beton öntözése 5 | 1h | 2011-11-10 17:00 | 2011-11-10 18:00 |  | 2d | start no earlier than 2011-11-10 17:00 |  |  |  |
| 13 | 7.6 | Beton öntözése 6 | 1h | 2011-11-11 17:00 | 2011-11-11 18:00 |  | 1d | start no earlier than 2011-11-11 17:00 |  |  |  |
| 14 | 7.7 | Beton öntözése 7 | 1h | 2011-11-12 17:00 | 2011-11-12 18:00 |  | 0d | start no earlier than 2011-11-12 17:00 |  |  |  |
| 15 | 8 | !száradás | 7d | 2011-11-06 09:00 | 2011-11-12 18:00 | 6 | 0d |  |  |  |  |
| 16 | 9 | Oszlopok festése | 2d | 2011-11-13 09:00 | 2011-11-14 18:00 | 15, 7, 6 | 0d |  | apa; fia; szerszámok | 42h |  |
| 17 | 10 | Drótkerítés felrakása | 2d | 2011-11-15 09:00 | 2011-11-16 18:00 | 16 | 0d |  | apa; fia; szerszámok; drótkerítés [40 m] | 42h | 16,000 |
